# Plantilla de calendario

Schedule from MS Project, 2022-01-10 to 2022-12-30, costs in S.

## Calendars

- Estándar: Mon-Fri 09:00-13:00, 15:00-19:00; Sat-Sun off.

## Resources

| Resource | Unit | Rate |
| --- | --- | --- |
| Topografo |  | 23.94 |
| Asistente de topografo |  | 17.08 |
| Operario | und | 23.94 |
| Oficial | bls | 18.89 |
| Peon | m3 | 17.08 |
| Jalon topografico |  | 1 |
| Nivel topografico |  | 9.75 |
| Teodolito topografico |  | 10.75 |
| Compresora neumatica 250 - 330 pcm 87 hp |  | 65 |
| Martillo neumatico de 29 kg |  | 32.5 |
| Cargador s/llanta 125-135 hp 3 yd3 |  | 175 |
| Excavadora s/orugas 115-165 hp |  | 295 |
| Camion volquete 15 m3 |  | 155 |
| Camion Cisterna 2000 gl (agua) |  | 123 |
| Rodillo Vib. Liso Aut. 7-9 t |  | 127.5 |
| Motoniveladora 125hp |  | 168 |
| Tractor de tiro Mf 265-63 hp |  | 72 |
| Barredora mecanica 10-20 hp |  | 73 |
| Camion Imprimador 1800 gl |  | 134 |
| Rodillo neumat. Aut. 5.5 - 20 t |  | 130 |
| Rodillo Tandem 8-10 t |  | 135 |
| Pavimentadora asfalto s/llantas 10'-16' |  | 165 |
| Compactadora Vib. Tipo plancha 7 hp |  | 48 |
| Rodillo Vib. Liso Aut.1.8 t |  | 55 |
| Material Granular (Subbase) | m3 | 48 |
| Material Granular (base) | m3 | 65 |
| Asfalto Liquido rc-250 | gl | 15 |
| Petroleo diesel N° 1 (kerosene Ind.) | gl | 14 |
| Clavo con Cabeza (promedio) | kg | 6 |
| Concreto Premezclado f'c = 210kg/cm2 t-1 | m3 | 300 |
| Aditivo liquido curador | gl | 23.5 |
| Madera tornillo para carpinteria | p2 | 7 |
| Mezcla asfaltica en caliente | m3 | 495 |
| Transporte de Mezcla asfaltica |  |  |
| Flete Terrestre en Plataforma (ida) |  |  |
| Flete Terrestre en Plataforma (vuelta) |  |  |
| Servicio de alquiler de contenedor |  |  |
| Disolvente Xilol | gl | 29 |
| Servicio de Fab. e Inst. Señal Informativa |  |  |
| Servicio de Fab. e Inst. Señal Octog. Preventiva |  |  |
| Pintura de transito | gl | 85 |
| Herramientas Manuales |  |  |
| Mira Topografica |  | 1.25 |

## Schedule

| ID | WBS | Task | Type | Duration | Start | Finish | Predecessors | Total slack | Free slack | Constraint | Cost | Dias Calendarios (dias) (Texto1) |
| --- | --- | --- | --- | --- | --- | --- | --- | --- | --- | --- | --- | --- |
| 1 | 1 | **CONSTRUCCION VIAL JR. RAMON CASTILLA** |  | 254.12d | 2022-01-10 | 2022-12-30 |  | 0d |  |  | 13,096,436.96 | 355 |
| 2 | 1.1 | INICIO | milestone | 0d | 2022-01-10 | 2022-01-10 |  | 0d |  | start no earlier than 2022-01-10 |  |  |
| 3 | 1.2 | **Obras Provisionales, trabajos Preliminares, Seguridad y Salud** |  | 143.12d | 2022-01-10 | 2022-07-28 |  | 0d |  |  | 91,801.4 | 200 |
| 4 | 1.2.1 | Movilizacion y desmovilización |  | 30d | 2022-01-10 | 2022-02-18 | 2 | 0d |  |  | 30,000 | 40 |
| 5 | 1.2.2 | Trazo y replanteo |  | 133.12d | 2022-01-24 | 2022-07-28 | 4FS-20d | 0d |  |  | 26,801.4 | 186 |
| 6 | 1.2.3 | Instalaciones provisionales |  | 30d | 2022-02-07 | 2022-03-18 | 4FS-10d | 77.12d | 46.12d |  | 35,000 | 40 |
| 7 | 1.3 | **Demoliciones y Movimiento de Tierras** |  | 119d | 2022-04-07 | 2022-09-21 |  | 0d |  |  | 3,615,213.12 | 168 |
| 8 | 1.3.1 | Demoliciones varias |  | 118d | 2022-04-07 | 2022-09-20 | 5FS-80d | 0d |  |  | 1,789,113.6 | 167 |
| 9 | 1.3.2 | Corte en material suelto para pavimentos |  | 71d | 2022-05-03 | 2022-08-10 | 8FS-100d, 6FS-15d | 31d | 0d |  | 198,364.32 | 100 |
| 10 | 1.3.3 | Eliminacion de excedente D = 18 km |  | 70d | 2022-06-15 | 2022-09-21 | 9FS-40d | 31d | 0d |  | 1,627,735.2 | 99 |
| 11 | 1.4 | **Pavimentos** |  | 67d | 2022-07-27 | 2022-10-28 |  | 31d |  |  | 7,468,959.44 | 94 |
| 12 | 1.4.1 | Conformacion de subrasante |  | 27d | 2022-07-27 | 2022-09-02 | 10FS-40d | 31d | 0d |  | 302,865.92 | 38 |
| 13 | 1.4.2 | Subbase granular e = 020 m |  | 41d | 2022-08-05 | 2022-10-03 | 12FS-20d | 31d | 0d |  | 1,640,509.36 | 60 |
| 14 | 1.4.3 | Base granular e = 0.20 m |  | 41d | 2022-08-22 | 2022-10-18 | 13FS-30d | 31d | 0d |  | 2,058,709.36 | 58 |
| 15 | 1.4.4 | Imprimacion asfaltica |  | 20d | 2022-09-23 | 2022-10-21 | 14FS-17d | 31d | 0d |  | 537,610.8 | 29 |
| 16 | 1.4.5 | Carpeta asfáltica en caliente e = 4 cm |  | 25d | 2022-09-23 | 2022-10-28 | 15FS-20d | 31d | 0d |  | 2,929,264 | 36 |
| 17 | 1.5 | **Obras de arte** |  | 125d | 2022-06-28 | 2022-12-20 |  | 0d |  |  | 1,819,916.7 | 176 |
| 18 | 1.5.1 | Excavación en material suelto para veredas y sardineles |  | 77d | 2022-06-28 | 2022-10-13 | 8FS-60d | 0d |  |  | 222,425.6 | 108 |
| 19 | 1.5.2 | Eliminacion de excedente D = 18 km |  | 13d | 2022-08-11 | 2022-08-30 | 18FS-45d | 0d |  |  | 100,764.56 | 20 |
| 20 | 1.5.3 | Conformacion de subrasante para veredas |  | 22d | 2022-08-30 | 2022-09-29 | 19 | 0d |  |  | 82,337.04 | 31 |
| 21 | 1.5.4 | Base para veredas e = 0.10 m |  | 35d | 2022-09-29 | 2022-11-17 | 20 | 0d |  |  | 429,484.8 | 50 |
| 22 | 1.5.5 | Veredas de concreto fc = 210 kg/cm2, e = 4" |  | 38d | 2022-10-27 | 2022-12-20 | 21FS-15d | 0d |  |  | 984,904.7 | 55 |
| 23 | 1.6 | **Señalización y Seguridad Vial** |  | 45d | 2022-10-28 | 2022-12-30 |  | 0d |  |  | 100,546.3 | 64 |
| 24 | 1.6.1 | Pintura zonal de simbolos y letras |  | 13d | 2022-10-28 | 2022-11-16 | 16 | 31d |  |  | 75,746.3 | 20 |
| 25 | 1.6.2 | Señales informativas |  | 5d | 2022-12-20 | 2022-12-27 | 24FS-7d, 22 | 0d |  |  | 13,200 |  |
| 26 | 1.6.3 | Señales preventivas octogonales 75 x 75 cm |  | 5d | 2022-12-23 | 2022-12-30 | 25FS-2d | 0d |  |  | 11,600 |  |
| 27 | 1.7 | FIN | milestone | 0d | 2022-12-30 | 2022-12-30 | 16, 22, 26 | 0d |  |  |  |  |
